# poroje

Schedule from MS Project, 2008-06-01 to 2008-08-07.
Luxury Custom Home Construction Schedule
B4UBUILD.COM - http://www.b4ubuild.com
This file is a partial schedule for trial use & inspection purposes only. Should you wish to purchase the file that contains the entire schedule, visit: / www.B4UBUILD.COM / You may also send a check or money order in the amount of $20.00 (USD) payable to: / B4UBUILD.COM / 10 Owl Branch Lane / Parkton, MD 21120-9522 / Please include your email address and registered owner contact information in your correspondence so that the full working file and a password, which unlocks it, may be sent to you.

## Calendars

- Standard: Mon-Fri 08:00-12:00, 13:00-17:00; Sat-Sun off.

## Resources

| Resource |
| --- |
| Sales Department |
| Construction Dept. |
| Sales Dept. |
| Client |
| County |
| County Sediment Control Inspector |
| Sediment Control Inspector |
| Department of Permits & Licenses |
| Building Inspector |
| Mason |
| Civil Engineer |
| Concrete Subcontractor |
| Concrete Subcontractor |
| Excavation Subcontractor |
| Masonry Subcontractor |
| Block Masonry Subcontractor |
| Steel Supplier |
| Lumber Supplier |
| Waterproofing Subcontractor |
| Lender |
| Framing Subcontractor |
| Pest Control Subcontractor |
| Mechanical Subcontractor |
| Plumbing Subcontractor |
| Field Superintendent |
| Plumbing Inspector |
| Electrical Subcontractor |
| Alarm Subcontractor |
| Client's Subcontractor |
| Electrical Inspector |
| Roofing Subcontractor |
| Exterior Trim Subcontractor |
| Brick Masonry Subcontractor |
| Insulation Subcontractor |
| BGE Inspector |
| Drywall Subcontractor |
| Painting Subcontractor |
| Trim Supplier |
| Interior Trim Subcontractor |
| Cabinet Subcontractor |
| Deck Subcontractor |
| Driveway Subcontractor |
| Seeding Subcontractor |
| Hardware Subcontractor |
| Mirror Subcontractor |
| Tile Subcontractor |
| Hardwood Floor Subcontractor |
| Carpet Subcontractor |
| Department of Licensing & Permits |
| Paint Subcontractor |
| Window Cleaning Subcontractor |
| Cleaning Subcontractor |
| Superintendent |
| Builder |
| Punch Out Crew |
| Stucco Subcontractor |
| Sales Manager |
| Construction Manager |
| Project Manager |

## Schedule

| ID | WBS | Task | Type | Duration | Start | Finish | Predecessors | Total slack | Free slack | Constraint | Resources | Work | تاریخ شروع پروژه |
| --- | --- | --- | --- | --- | --- | --- | --- | --- | --- | --- | --- | --- | --- |
| 1 | 1 | **قراردادها** |  | 0d | 2008-06-01 | 2008-06-01 |  | 0d |  |  |  |  | 78/10/93 |
| 2 | 1.1 | توافق فروش | milestone | 0d | 2008-06-01 | 2008-06-01 |  | 49d |  |  | Builder |  |  |
| 3 | 1.2 | قرارداد ساخت و ساز | milestone | 0d | 2008-06-01 | 2008-06-01 |  | 0d |  |  | Builder |  |  |
| 4 | 1.3 | طرح قرارداد | milestone | 0d | 2008-06-01 | 2008-06-01 | 3 | 4d | 0d |  | Builder |  |  |
| 5 | 1.4 | مشخصات قرارداد | milestone | 0d | 2008-06-01 | 2008-06-01 | 3 | 0d |  |  | Builder |  |  |
| 6 | 1.5 | طراحی سایت | milestone | 0d | 2008-06-01 | 2008-06-01 | 3 | 19d | 15d |  | Builder |  |  |
| 7 | 1.6 | تامین هزینه ها | milestone | 0d | 2008-06-01 | 2008-06-01 |  | 49d |  |  | Client |  |  |
| 8 | 1.7 | وام ساخت و ساز | milestone | 0d | 2008-06-01 | 2008-06-01 |  | 49d |  |  | Client |  |  |
| 9 | 2 | **بررسی سند و ویرایش** |  | 25d | 2008-06-02 | 2008-07-04 |  | 0d |  |  |  | 328h |  |
| 10 | 2.1 | نقد و بررسی طرح نهایی |  | 15d | 2008-06-02 | 2008-06-20 | 4 | 4d | 0d |  | Builder | 120h |  |
| 11 | 2.2 | نقد و بررسی و نهایی کردن مشخصات |  | 20d | 2008-06-02 | 2008-06-27 | 5 | 0d |  |  | Builder | 160h |  |
| 12 | 2.3 | نقد و بررسی و نهایی کردن طرح سایت |  | 1d | 2008-06-23 | 2008-06-23 | 6, 10 | 4d |  |  | Builder | 8h |  |
| 13 | 2.4 | طراحی ساخت و ساز |  | 5d | 2008-06-30 | 2008-07-04 | 10, 11, 12 | 0d |  |  | Builder | 40h |  |
| 14 | 2.5 | تصویب طرح | milestone | 0d | 2008-07-04 | 2008-07-04 | 13 | 0d |  |  | Client |  |  |
| 15 | 2.6 | تایید مشخصات فنی | milestone | 0d | 2008-07-04 | 2008-07-04 | 13 | 1d | 0d |  | Client |  |  |
| 16 | 2.7 | تصویب طرح سایت | milestone | 0d | 2008-07-04 | 2008-07-04 | 13 | 16d | 0d |  | Client |  |  |
| 17 | 3 | **مناقصات و قراردادها** |  | 24d | 2008-07-07 | 2008-08-07 |  | 0d |  |  |  | 248h |  |
| 18 | 3.1 | ایجاد کپی از برنامه |  | 3d | 2008-07-07 | 2008-07-09 | 14 | 0d |  |  | Builder | 24h |  |
| 19 | 3.2 | ایجاد کپی از مشخصات فنی |  | 2d | 2008-07-07 | 2008-07-08 | 15 | 1d |  |  | Builder | 16h |  |
| 20 | 3.3 | پخش برنامه ها و مشخصات |  | 1d | 2008-07-10 | 2008-07-10 | 18, 19 | 0d |  | start no earlier than 1996-08-17 | Builder | 8h |  |
| 21 | 3.4 | دریافت قیمت های پیشنهادی |  | 10d | 2008-07-11 | 2008-07-24 | 20 | 0d |  | start no earlier than 1996-08-17 | Builder | 80h |  |
| 22 | 3.5 | **نقد و بررسی قیمت های پیشنهادی** |  | 5d | 2008-07-25 | 2008-07-31 |  | 0d |  |  |  | 80h |  |
| 23 | 3.5.1 | فروش |  | 5d | 2008-07-25 | 2008-07-31 | 21 | 0d |  |  | Builder | 40h |  |
| 24 | 3.5.2 | ساخت و ساز |  | 5d | 2008-07-25 | 2008-07-31 | 21 | 5d |  |  | Builder | 40h |  |
| 25 | 3.6 | اجرای موافقت نامه های فرعی |  | 5d | 2008-08-01 | 2008-08-07 | 23 | 0d |  | start no earlier than 1996-08-17 | Builder | 40h |  |

| ID | WBS | Task | Type | Duration | Start | Finish | Predecessors | Total slack | Free slack | Resources | Work |
| --- | --- | --- | --- | --- | --- | --- | --- | --- | --- | --- | --- |
| 26 | 4 | **درجه بندی پروانه های ساختمان** |  | 35d | 2008-06-02 | 2008-07-18 |  | 14d |  |  | 112h |
| 27 | 4.1 | برنامه های ریسک |  | 1d | 2008-07-07 | 2008-07-07 | 13 | 14d | 0d | Builder | 8h |
| 28 | 4.2 | تعداد سهام |  | 1d | 2008-07-11 | 2008-07-11 | 27FS+3d | 14d | 0d | Civil Engineer | 8h |
| 29 | 4.4 | فایل های پروانه ساختمان |  | 3d | 2008-07-07 | 2008-07-09 | 14, 15, 16 | 16d | 2d | Builder | 24h |
| 30 | 4.5 | شناسایی سهام ارسالی |  | 1d | 2008-07-14 | 2008-07-14 | 28, 29 | 14d | 0d | Builder | 8h |
| 31 | 4.6 | دیدار با بازرس کنترلی |  | 1d | 2008-07-15 | 2008-07-15 | 28, 30 | 14d | 0d | Builder | 8h |
| 32 | 4.7 | دیدار با مالکان |  | 1d | 2008-07-16 | 2008-07-16 | 31 | 14d | 0d | Builder | 8h |
| 33 | 4.8 | ساخت و ساز ورودی |  | 1d | 2008-07-17 | 2008-07-17 | 31, 32 | 15d |  | Excavation Subcontractor | 8h |
| 34 | 4.9 | کنترل ساخت و ساز |  | 2d | 2008-07-17 | 2008-07-18 | 31, 32 | 14d |  | Excavation Subcontractor | 16h |
| 35 | 4.11 | نمره دهی به پروانه |  | 1d | 2008-06-02 | 2008-06-02 |  | 43d | 0d | Sediment Control Inspector | 8h |
| 36 | 4.13 | تایید جواز ساختمان |  | 1d | 2008-06-03 | 2008-06-03 | 35 | 44d | 0d | Department of Permits & Licenses | 8h |
| 37 | 4.14 | پرداخت هزینه مجوز |  | 1d | 2008-06-06 | 2008-06-06 | 36FS+2d | 44d | 0d | Builder | 8h |
| 38 | 4.15 | مجوز ساختمان صادر شود | milestone | 0d | 2008-06-06 | 2008-06-06 | 37 | 44d |  | Department of Permits & Licenses |  |
| 39 | 5 | **کار سایت** |  | 5d | 2008-06-03 | 2008-06-09 |  | 43d |  |  | 48h |
| 40 | 5.1 | پاک کردن مالکان |  | 3d | 2008-06-03 | 2008-06-05 | 35 | 43d | 0d | Excavation Subcontractor | 24h |
| 41 | 5.2 | ثبت اطلاعات |  | 1d | 2008-06-06 | 2008-06-06 | 40 | 44d |  | Excavation Subcontractor | 8h |
| 42 | 5.3 | دادن اطلاعات |  | 1d | 2008-06-06 | 2008-06-06 | 40 | 43d | 0d | Civil Engineer | 8h |
| 43 | 5.4 | ثبت نظرات |  | 1d | 2008-06-09 | 2008-06-09 | 40, 42 | 43d |  | Excavation Subcontractor | 8h |
| 44 | 6 | **تاسیسات** |  | 20d | 2008-06-02 | 2008-06-27 |  | 29d |  |  | 192h |
| 45 | 6.1 | شالوده های متکی بر طرح |  | 1d | 2008-06-02 | 2008-06-02 |  | 47d | 0d | Concrete Subcontractor | 8h |
| 46 | 6.2 | نصب تقویت کننده ها |  | 1d | 2008-06-03 | 2008-06-03 | 45 | 47d | 0d | Concrete Subcontractor | 8h |
| 47 | 6.3 | بررسی موقعیت | milestone | 0d | 2008-06-03 | 2008-06-03 | 46 | 47d |  | Building Inspector |  |
| 48 | 6.6 | مصالح |  | 1d | 2008-06-02 | 2008-06-02 |  | 29d | 0d | Block Masonry Subcontractor | 8h |
| 49 | 6.7 | ساخت زیرساخت |  | 15d | 2008-06-03 | 2008-06-23 | 48 | 29d | 0d | Block Masonry Subcontractor | 120h |
| 50 | 6.8 | صدور گواهینامه های پایه | milestone | 0d | 2008-06-23 | 2008-06-23 | 49 | 33d | 0d | Civil Engineer |  |
| 51 | 6.9 | بررسی محل سکونت | milestone | 0d | 2008-06-23 | 2008-06-23 | 50 | 33d |  | Lender |  |
| 52 | 6.10 | هزینه بتن ریزی |  | 1d | 2008-06-24 | 2008-06-24 | 49 | 29d | 0d | Block Masonry Subcontractor | 8h |
| 53 | 6.11 | مصالح فولادی |  | 1d | 2008-06-25 | 2008-06-25 | 52 | 29d | 0d | Steel Supplier | 8h |
| 54 | 6.12 | هزینه نصب |  | 2d | 2008-06-26 | 2008-06-27 | 53 | 29d |  | Block Masonry Subcontractor | 16h |
| 55 | 6.13 | مصالح چوبی |  | 1d | 2008-06-25 | 2008-06-25 | 52 | 30d | 0d | Lumber Supplier | 8h |
| 56 | 6.14 | فاضلاب کشی |  | 1d | 2008-06-26 | 2008-06-26 | 55 | 30d |  | Waterproofing Subcontractor | 8h |
